# Zmiana lokalizacji

How a schedule from MS Project changed from version to version. A marks actual dates.

## Version 1 (saved 2007-04-17, file 9_1.mpp)

| ID | WBS | Task | Duration | Start | Finish | Predecessors | Total float | Constraint |
| --- | --- | --- | --- | --- | --- | --- | --- | --- |
| 1 |  | Start | 0d | 2008-04-01 09:00 | 2008-04-01 09:00 |  | 3.5d |  |
| 2 | 2 | **Poszukiwanie lokalu** | 13.62d? | 2008-04-01 09:00 | 2008-04-18 15:00 |  | 0.5d |  |
| 3 |  | Określenie potrzeb | 1d | 2008-04-01 09:00 | 2008-04-01 18:00 | 1 | 3.5d |  |
| 4 |  | Przygotowanie ogłoszenia | 0.5d? | 2008-04-02 09:00 | 2008-04-02 13:00 | 3 | 3.5d | finish no later than 2008-04-07 18:00 |
| 5 |  | Emisja ogłoszenia | 1d | 2008-04-10 09:00 | 2008-04-10 18:00 | 4 | 0d | must start on 2008-04-10 09:00 |
| 6 | 2.4 | **Rozpatrywanie ofert** | 10.62d? | 2008-04-02 14:00 | 2008-04-17 10:00 |  | 0.38d |  |
| 7 | 2.4.1 | **Ocena ofert** | 10.62d? | 2008-04-02 14:00 | 2008-04-17 10:00 |  | 0.38d |  |
| 8 |  | Definiowanie kryteriów oceny | 0.5d | 2008-04-02 14:00 | 2008-04-02 18:00 | 4 | 6d |  |
| 9 |  | Wpisywanie zgłoszonych ofert | 1d? | 2008-04-11 09:00 | 2008-04-11 18:00 | 5, 8 | 0d |  |
| 10 |  | Wizyty w lokalach | 3d? | 2008-04-14 09:00 | 2008-04-16 18:00 | 9 | 0d |  |
| 11 |  | Przypisywanie ocen | 1d | 2008-04-16 18:00 | 2008-04-17 10:00 | 10FF | 0.5d |  |
| 12 |  | Spisanie i zebranie ocen | 1d | 2008-04-17 10:00 | 2008-04-18 10:00 | 11 | 0.5d |  |
| 13 |  | Wybór lokalu | 0d | 2008-04-18 10:00 | 2008-04-18 10:00 | 12 | 0.5d |  |
| 14 |  | Wysyłanie powiadomień o decyzji | 0.5d | 2008-04-18 10:00 | 2008-04-18 15:00 | 13 | 0.5d |  |
| 15 | 3 | **Przygotowania do przeprowadzki** | 25.67d? | 2008-04-21 09:00 | 2008-05-28 15:20 |  | 0.12d |  |
| 16 |  | Opiniowanie umowy | 2d | 2008-04-21 09:00 | 2008-04-23 13:00 | 14 | 0d |  |
| 17 |  | Podpisanie umowy | 2h | 2008-04-23 14:00 | 2008-04-23 16:00 | 16 | 0d |  |
| 18 |  | Wypowiedzenie umowy | 1h | 2008-04-23 12:00 | 2008-04-23 14:00 | 17SF | 28.15d |  |
| 19 |  | Zdanie lokalu | 0.33d? | 2008-05-28 11:40 | 2008-05-28 15:20 | 26 | 4.98d |  |
| 20 |  | Ustalenie terminu przeprowadzki | 0d? | 2008-04-23 16:00 | 2008-04-23 16:00 | 17 | 19d |  |
| 21 |  | Aranżacja wnętrz | 1mo | 2008-04-23 16:00 | 2008-05-23 16:00 | 17 | 0d |  |
| 22 | 4 | **Przeprowadzka** | 27.9d | 2008-04-23 16:00 | 2008-06-04 15:10 |  | 0d |  |
| 23 |  | Poszukiwanie środka transportu | 1d | 2008-04-23 16:00 | 2008-04-24 16:00 | 20 | 19d |  |
| 24 |  | Odebranie lokalu | 1.62d | 2008-05-23 16:00 | 2008-05-26 16:00 | 21, 23 | 0d |  |
| 25 |  | Pakowanie wyposażenia | 1.33d | 2008-05-26 16:00 | 2008-05-28 09:40 | 21, 24 | 0d |  |
| 26 |  | Wynoszenie wyposażenia | 2h | 2008-05-28 09:40 | 2008-05-28 11:40 | 25 | 0d |  |
| 27 |  | Załadunek | 1h | 2008-05-28 11:10 | 2008-05-28 12:10 | 26FS-2.5% | 0d |  |
| 28 |  | Transport | 0.5h | 2008-05-28 12:10 | 2008-05-28 12:40 | 27 | 0d |  |
| 29 |  | Wyładunek | 1h | 2008-05-28 12:40 | 2008-05-28 14:40 | 28 | 0d |  |
| 30 |  | Wnoszenie wyposażenia | 2h | 2008-05-28 14:10 | 2008-05-28 16:10 | 29FS-5% | 0d |  |
| 31 |  | Rozlokowanie sprzętu | 4d | 2008-05-28 14:40 | 2008-06-03 14:40 | 30FS-7.5% | 0.06d |  |
| 32 |  | Rozlokowanie wyposażenia | 4d | 2008-05-28 15:10 | 2008-06-03 15:10 | 30FS-5% | 0d |  |
| 33 |  | Sprzątanie | 1d | 2008-06-03 15:10 | 2008-06-04 15:10 | 31, 32 | 0d |  |
| 34 |  | Koniec | 0d | 2008-06-04 15:10 | 2008-06-04 15:10 | 19, 33 | 0d |  |
| 35 | 6 | **Przygotowanie raportu** | 38.25d | 2008-04-04 09:00 | 2008-05-30 11:00 |  | 3.4d |  |
| 36 |  | Przygotowanie raportu 1 | 2h | 2008-04-04 09:00 | 2008-04-04 11:00 |  | 38.06d | start no earlier than 2008-04-04 09:00 |
| 37 |  | Przygotowanie raportu 2 | 2h | 2008-04-11 09:00 | 2008-04-11 11:00 |  | 33.06d | start no earlier than 2008-04-11 09:00 |
| 38 |  | Przygotowanie raportu 3 | 2h | 2008-04-18 09:00 | 2008-04-18 11:00 |  | 28.06d | start no earlier than 2008-04-18 09:00 |
| 39 |  | Przygotowanie raportu 4 | 2h | 2008-04-25 09:00 | 2008-04-25 11:00 |  | 23.06d | start no earlier than 2008-04-25 09:00 |
| 40 |  | Przygotowanie raportu 5 | 2h | 2008-05-02 09:00 | 2008-05-02 11:00 |  | 19.06d | start no earlier than 2008-05-02 09:00 |
| 41 |  | Przygotowanie raportu 6 | 2h | 2008-05-09 09:00 | 2008-05-09 11:00 |  | 14.06d | start no earlier than 2008-05-09 09:00 |
| 42 |  | Przygotowanie raportu 7 | 2h | 2008-05-16 09:00 | 2008-05-16 11:00 |  | 9.06d | start no earlier than 2008-05-16 09:00 |
| 43 |  | Przygotowanie raportu 8 | 2h | 2008-05-23 09:00 | 2008-05-23 11:00 |  | 5.06d | start no earlier than 2008-05-23 09:00 |
| 44 |  | Przygotowanie raportu 9 | 2h | 2008-05-30 09:00 | 2008-05-30 11:00 |  | 0.06d | start no earlier than 2008-05-30 09:00 |

## Version 2 (data date 2008-04-30, saved 2007-04-17, file 9_3.mpp)

Last finish stays 2008-06-04. Complete tasks 0 → 20.

Changed:

| ID | Task | Start | Finish | Complete | Total float |
| --- | --- | --- | --- | --- | --- |
| 1 | Start | 2008-04-01 09:00 A | 2008-04-01 09:00 A | 0% → 100% | 3.5d → none |
| 2 | **Poszukiwanie lokalu** | 2008-04-01 09:00 A | 2008-04-18 15:00 A | 0% → 100% | 0.5d → none |
| 3 | Określenie potrzeb | 2008-04-01 09:00 A | 2008-04-01 18:00 A | 0% → 100% | 3.5d → none |
| 4 | Przygotowanie ogłoszenia | 2008-04-02 09:00 A | 2008-04-02 13:00 A | 0% → 100% | 3.5d → none |
| 5 | Emisja ogłoszenia | 2008-04-10 09:00 A | 2008-04-10 18:00 A | 0% → 100% | 0d → none |
| 6 | **Rozpatrywanie ofert** | 2008-04-02 14:00 A | 2008-04-17 10:00 A | 0% → 100% | 0.38d → none |
| 7 | **Ocena ofert** | 2008-04-02 14:00 A | 2008-04-17 10:00 A | 0% → 100% | 0.38d → none |
| 8 | Definiowanie kryteriów oceny | 2008-04-02 14:00 A | 2008-04-02 18:00 A | 0% → 100% | 6d → none |
| 9 | Wpisywanie zgłoszonych ofert | 2008-04-11 09:00 A | 2008-04-11 18:00 A | 0% → 100% | 0d → none |
| 10 | Wizyty w lokalach | 2008-04-14 09:00 A | 2008-04-16 18:00 A | 0% → 100% | 0d → none |
| 11 | Przypisywanie ocen | 2008-04-16 18:00 A | 2008-04-17 10:00 A | 0% → 100% | 0.5d → none |
| 12 | Spisanie i zebranie ocen | 2008-04-17 10:00 A | 2008-04-18 10:00 A | 0% → 100% | 0.5d → none |
| 13 | Wybór lokalu | 2008-04-18 10:00 A | 2008-04-18 10:00 A | 0% → 100% | 0.5d → none |
| 14 | Wysyłanie powiadomień o decyzji | 2008-04-18 10:00 A | 2008-04-18 15:00 A | 0% → 100% | 0.5d → none |
| 15 | **Przygotowania do przeprowadzki** | 2008-04-21 09:00 A |  | 0% → 29% | 0.12d → 4.98d |
| 16 | Opiniowanie umowy | 2008-04-21 09:00 A | 2008-04-23 13:00 A | 0% → 100% | 0d → none |
| 17 | Podpisanie umowy | 2008-04-23 14:00 A | 2008-04-23 16:00 A | 0% → 100% | 0d → none |
| 18 | Wypowiedzenie umowy | 2008-04-23 12:00 A | 2008-04-23 14:00 A | 0% → 100% | 28.15d → none |
| 20 | Ustalenie terminu przeprowadzki | 2008-04-23 16:00 A | 2008-04-23 16:00 → 2008-04-23 16:01 A | 0% → 100% | 19d → none |
| 21 | Aranżacja wnętrz | 2008-04-23 16:00 A |  | 0% → 21% |  |
| 22 | **Przeprowadzka** | 2008-04-23 16:00 A |  | 0% → 7% |  |
| 23 | Poszukiwanie środka transportu | 2008-04-23 16:00 A | 2008-04-24 16:00 A | 0% → 100% | 19d → none |
| 35 | **Przygotowanie raportu** | 2008-04-04 09:00 A |  | 0% → 44% |  |
| 36 | Przygotowanie raportu 1 | 2008-04-04 09:00 A | 2008-04-04 11:00 A | 0% → 100% | 38.06d → none |
| 37 | Przygotowanie raportu 2 | 2008-04-11 09:00 A | 2008-04-11 11:00 A | 0% → 100% | 33.06d → none |
| 38 | Przygotowanie raportu 3 | 2008-04-18 09:00 A | 2008-04-18 11:00 A | 0% → 100% | 28.06d → none |
| 39 | Przygotowanie raportu 4 | 2008-04-25 09:00 A | 2008-04-25 11:00 A | 0% → 100% | 23.06d → none |

## Version 3 (data date 2008-04-30, saved 2007-04-17, file 9_4.mpp)

Last finish 2008-06-04 → 2008-06-11 (+7d). Complete tasks 20 → 21.

Changed:

| ID | Task | Start | Finish | Duration | Complete | Total float |
| --- | --- | --- | --- | --- | --- | --- |
| 15 | **Przygotowania do przeprowadzki** |  | 2008-05-28 15:20 → 2008-06-04 17:20 (+7d) | 25.67d? → 30.92d? | 29% → 99% |  |
| 19 | Zdanie lokalu | 2008-05-28 11:40 → 2008-06-04 14:40 (+7d) | 2008-05-28 15:20 → 2008-06-04 17:20 (+7d) |  |  |  |
| 21 | Aranżacja wnętrz |  | 2008-05-23 16:00 → 2008-05-30 18:00 A (+7d) | 1mo → 1.26mo | 21% → 100% | 0d → none |
| 22 | **Przeprowadzka** |  | 2008-06-04 15:10 → 2008-06-11 17:10 (+7d) | 27.9d → 33.15d |  |  |
| 24 | Odebranie lokalu | 2008-05-23 16:00 → 2008-05-31 09:00 (+8d) | 2008-05-26 16:00 → 2008-06-02 18:00 (+7d) |  |  |  |
| 25 | Pakowanie wyposażenia | 2008-05-26 16:00 → 2008-06-03 09:00 (+8d) | 2008-05-28 09:40 → 2008-06-04 11:40 (+7d) |  |  |  |
| 26 | Wynoszenie wyposażenia | 2008-05-28 09:40 → 2008-06-04 11:40 (+7d) | 2008-05-28 11:40 → 2008-06-04 14:40 (+7d) |  |  |  |
| 27 | Załadunek | 2008-05-28 11:10 → 2008-06-04 14:10 (+7d) | 2008-05-28 12:10 → 2008-06-04 15:10 (+7d) |  |  |  |
| 28 | Transport | 2008-05-28 12:10 → 2008-06-04 15:10 (+7d) | 2008-05-28 12:40 → 2008-06-04 15:40 (+7d) |  |  |  |
| 29 | Wyładunek | 2008-05-28 12:40 → 2008-06-04 15:40 (+7d) | 2008-05-28 14:40 → 2008-06-04 16:40 (+7d) |  |  |  |
| 30 | Wnoszenie wyposażenia | 2008-05-28 14:10 → 2008-06-04 16:10 (+7d) | 2008-05-28 16:10 → 2008-06-05 09:10 (+8d) |  |  |  |
| 31 | Rozlokowanie sprzętu | 2008-05-28 14:40 → 2008-06-04 16:40 (+7d) | 2008-06-03 14:40 → 2008-06-10 16:40 (+7d) |  |  |  |
| 32 | Rozlokowanie wyposażenia | 2008-05-28 15:10 → 2008-06-04 17:10 (+7d) | 2008-06-03 15:10 → 2008-06-10 17:10 (+7d) |  |  |  |
| 33 | Sprzątanie | 2008-06-03 15:10 → 2008-06-10 17:10 (+7d) | 2008-06-04 15:10 → 2008-06-11 17:10 (+7d) |  |  |  |
| 34 | Koniec | 2008-06-04 15:10 → 2008-06-11 17:10 (+7d) | 2008-06-04 15:10 → 2008-06-11 17:10 (+7d) |  |  |  |

## Version 4 (data date 2008-04-30, saved 2007-04-17, file 9_5.mpp)

Last finish 2008-06-11 → 2008-06-12 (+1d). Complete tasks 21 → 26.

Changed:

| ID | Task | Start | Finish | Duration | Complete | Total float | Other |
| --- | --- | --- | --- | --- | --- | --- | --- |
| 22 | **Przeprowadzka** |  | 2008-06-11 17:10 → 2008-06-12 09:10 (+1d) | 33.15d → 33.27d | 7% → 33% |  |  |
| 24 | Odebranie lokalu | 2008-05-31 09:00 A | 2008-06-02 18:00 A |  | 0% → 100% | 0d → none |  |
| 25 | Pakowanie wyposażenia | 2008-06-03 09:00 A | 2008-06-04 11:40 → 2008-06-04 13:00 A | 1.33d → 1.5d | 0% → 100% | 0d → none | resources Pracownik pomocniczy [300%] → Pracownik pomocniczy [266.7%] |
| 26 | Wynoszenie wyposażenia | 2008-06-04 11:40 A | 2008-06-04 14:40 A |  | 0% → 100% | 0d → none |  |
| 27 | Załadunek | 2008-06-04 14:10 A | 2008-06-04 15:10 → 2008-06-04 15:40 A | 1h → 1.5h | 0% → 100% | 0d → none |  |
| 28 | Transport | 2008-06-04 15:10 → 2008-06-04 15:40 A | 2008-06-04 15:40 → 2008-06-04 16:40 A | 0.5h → 1h | 0% → 100% | 0d → none |  |
| 29 | Wyładunek | 2008-06-04 15:40 → 2008-06-04 16:40 | 2008-06-04 16:40 → 2008-06-04 17:40 |  |  |  |  |
| 30 | Wnoszenie wyposażenia | 2008-06-04 16:10 → 2008-06-04 17:10 | 2008-06-05 09:10 → 2008-06-05 10:10 |  |  |  |  |
| 31 | Rozlokowanie sprzętu | 2008-06-04 16:40 → 2008-06-04 17:40 | 2008-06-10 16:40 → 2008-06-10 17:40 |  |  |  |  |
| 32 | Rozlokowanie wyposażenia | 2008-06-04 17:10 → 2008-06-05 09:10 (+1d) | 2008-06-10 17:10 → 2008-06-11 09:10 (+1d) |  |  |  |  |
| 33 | Sprzątanie | 2008-06-10 17:10 → 2008-06-11 09:10 (+1d) | 2008-06-11 17:10 → 2008-06-12 09:10 (+1d) |  |  |  |  |
| 34 | Koniec | 2008-06-11 17:10 → 2008-06-12 09:10 (+1d) | 2008-06-11 17:10 → 2008-06-12 09:10 (+1d) |  |  |  |  |
